# CKM Office Renovation

Schedule from MS Project, 2018-05-07 to 2018-06-14, 7 hours a day, costs in $.
Office Renovation Project
Corporate Knowledge Management

## Calendars

- Standard: Mon-Fri 09:00-13:00, 14:00-17:00; Sat-Sun off.

## Resources

| Resource | Group | Unit | Rate | Cost per use |
| --- | --- | --- | --- | --- |
| Carpenter | Contractor |  | 35 |  |
| Carpet | Materials | Lin Metre | 100 |  |
| Carpet Contractor | Contractor |  |  |  |
| Fit-out Consultant | Consultant |  | 65 | 50 |
| Furniture | Asset |  |  |  |
| Gyprock | Material | Sheet | 30 |  |
| Plaster | Material | Bag | 50 |  |
| IT Consultant | Contractor |  | 80 |  |
| Labourer | Contractor |  | 20 |  |
| Management | Staff |  | 100 |  |
| Network Cable & Points | Asset |  |  |  |
| PABX & Points | Asset |  |  |  |
| Paint | Material | Litre | 250 |  |
| Painter | Contractor |  | 35 |  |
| Personal Computers | Asset |  |  |  |
| Phones | Asset |  |  |  |
| Plasterer | Contractor |  | 35 |  |
| Project Manager | Staff |  | 80 |  |
| Staff | Staff |  | 50 |  |
| Telecommunications consultant | Consultant |  | 60 |  |
| Admin Assistant | Staff |  | 45 |  |

## Schedule

| ID | WBS | Task | Type | Duration | Start | Finish | Predecessors | Baseline start | Baseline finish | Baseline duration | Total slack | Free slack | Deadline | Resources | Work | Cost | Baseline cost |
| --- | --- | --- | --- | --- | --- | --- | --- | --- | --- | --- | --- | --- | --- | --- | --- | --- | --- |
| 1 | 1 | **Planning & Research** |  | 8.43d | 2018-05-07 09:00 | 2018-05-17 12:00 |  | 2011-04-04 09:00 | 2011-04-14 12:00 | 8.43d | 0d |  |  |  | 24h | 2,112 | 1,920 |
| 2 | 1.1 | Develop Requirements Documentation |  | 1d | 2018-05-07 09:00 | 2018-05-07 17:00 |  | 2011-04-04 09:00 | 2011-04-04 17:00 | 1d | 0d |  | 2018-05-07 17:00 | Project Manager | 7h | 616 | 560 |
| 3 | 1.2 | Fit-Out Consultant Research |  | 0.5d | 2018-05-08 09:00 | 2018-05-08 12:30 | 2 | 2011-04-05 09:00 | 2011-04-05 12:30 | 0.5d | 0.5d | 0d |  | Project Manager | 3.5h | 308 | 280 |
| 4 | 1.3 | Telecommunications Consultant Research |  | 0.5d | 2018-05-08 12:30 | 2018-05-08 17:00 | 3 | 2011-04-05 12:30 | 2011-04-05 17:00 | 0.5d | 0.5d | 0d |  | Project Manager | 3.5h | 308 | 280 |
| 5 | 1.4 | IT Network Contractor Research |  | 0.5d | 2018-05-09 09:00 | 2018-05-09 12:30 | 4 | 2011-04-06 09:00 | 2011-04-06 12:30 | 0.5d | 0.5d | 0d |  | Project Manager | 3.5h | 308 | 280 |
| 6 | 1.5 | Building Contractors Research |  | 0.5d | 2018-05-09 12:30 | 2018-05-09 17:00 | 5 | 2011-04-06 12:30 | 2011-04-06 17:00 | 0.5d | 0.5d | 0d |  | Project Manager | 3.5h | 308 | 280 |
| 7 | 1.6 | Submit Requirements to Resources & Request Quotes |  | 2h | 2018-05-10 09:00 | 2018-05-10 11:00 | 6 | 2011-04-07 09:00 | 2011-04-07 11:00 | 2h | 0.5d | 0d |  | Project Manager | 2h | 176 | 160 |
| 8 | 1.7 | Quotes Received |  | 1h | 2018-05-17 11:00 | 2018-05-17 12:00 | 7FS+5d | 2011-04-14 11:00 | 2011-04-14 12:00 | 1h | 0.5d | 0d |  | Project Manager | 1h | 88 | 80 |
| 9 | 1.8 | Planning & Research Complete | milestone | 0d | 2018-05-17 12:00 | 2018-05-17 12:00 | 8 | 2011-04-14 12:00 | 2011-04-14 12:00 | 0d | 0.5d | 0d |  |  |  |  |  |
| 10 | 2 | **Management Approval** |  | 1.79d | 2018-05-17 12:00 | 2018-05-21 10:30 |  | 2011-04-14 12:00 | 2011-04-15 15:00 | 1.29d | 0.5d |  |  |  | 13.5h | 1,200 | 820 |
| 11 | 2.1 | Consolidate Quotes and develop proposal |  | 1.5d | 2018-05-17 12:00 | 2018-05-18 16:30 | 9 | 2011-04-14 12:00 | 2011-04-15 12:00 | 1d | 0.5d | 0d |  | Project Manager | 10.5h | 924 | 560 |
| 12 | 2.2 | Develop Project Plan & Durations |  | 1h | 2018-05-18 16:30 | 2018-05-21 09:30 | 11 | 2011-04-15 12:00 | 2011-04-15 13:00 | 1h | 0.5d | 0d |  | Project Manager | 1h | 88 | 80 |
| 13 | 2.3 | Submit Project Plan & Costs to Management |  | 1h | 2018-05-21 09:30 | 2018-05-21 10:30 | 12 | 2011-04-15 14:00 | 2011-04-15 15:00 | 1h | 0.5d | 0d |  | Project Manager; Management | 2h | 188 | 180 |
| 14 | 2.4 | Management Approval Received | milestone | 0d | 2018-05-21 10:30 | 2018-05-21 10:30 | 13 | 2011-04-15 15:00 | 2011-04-15 15:00 | 0d | 0.5d | 0d |  |  |  |  |  |
| 15 | 3 | **Refit Office** |  | 14.79d | 2018-05-21 10:30 | 2018-06-08 17:00 |  | 2011-04-15 15:00 | 2011-05-11 17:00 | 15.29d | 0.5d |  |  |  | 111.5h | 76,763.5 | 76,607.5 |
| 16 | 3.1 | Appoint Resources |  | 2h | 2018-05-21 10:30 | 2018-05-21 12:30 | 14 | 2011-04-15 15:00 | 2011-04-15 17:00 | 2h | 0.5d | 0d |  | Project Manager | 2h | 176 | 160 |
| 17 | 3.2 | Staff Briefing |  | 1h | 2018-05-21 12:30 | 2018-05-21 14:30 | 16 | 2011-04-18 09:00 | 2011-04-18 10:00 | 1h | 0.5d | 0d |  | Project Manager; Staff [700%] | 8h | 438 | 430 |
| 18 | 3.3 | **Fit-Out Consultations** |  | 0.93d | 2018-05-21 14:30 | 2018-05-22 13:00 |  | 2011-04-18 10:00 | 2011-04-19 09:30 | 0.93d | 0.5d |  |  |  | 13h | 1,194.5 | 1,142.5 |
| 19 | 3.3.1 | Office Space / Structure Plan |  | 0.5d | 2018-05-21 14:30 | 2018-05-22 10:00 | 17 | 2011-04-18 10:00 | 2011-04-18 14:30 | 0.5d | 0.5d | 0d |  | Fit-out Consultant; Project Manager | 7h | 585.5 | 557.5 |
| 20 | 3.3.2 | Select & Order Carpet |  | 1h | 2018-05-22 10:00 | 2018-05-22 11:00 | 19 | 2011-04-18 14:30 | 2011-04-18 15:30 | 1h | 0.5d | 0d |  | Fit-out Consultant; Project Manager | 2h | 203 | 195 |
| 21 | 3.3.3 | Select & Order Paint |  | 1h | 2018-05-22 11:00 | 2018-05-22 12:00 | 20 | 2011-04-18 15:30 | 2011-04-18 16:30 | 1h | 0.5d | 0d |  | Fit-out Consultant; Project Manager | 2h | 203 | 195 |
| 22 | 3.3.4 | Select & Order Office Furniture |  | 1h | 2018-05-22 12:00 | 2018-05-22 13:00 | 21 | 2011-04-18 16:30 | 2011-04-19 09:30 | 1h | 0.5d | 0d |  | Fit-out Consultant; Project Manager | 2h | 203 | 195 |
| 23 | 3.4 | **Telecommuncations Consultations** |  | 0.64d | 2018-05-22 14:00 | 2018-05-23 10:30 |  | 2011-04-19 09:30 | 2011-04-19 15:00 | 0.64d | 0.5d |  |  |  | 8h | 606 | 570 |
| 24 | 3.4.1 | Design Telephone Access Points Map |  | 0.5d | 2018-05-22 14:00 | 2018-05-23 09:30 | 22 | 2011-04-19 09:30 | 2011-04-19 13:00 | 0.5d | 0.5d | 0d |  | Project Manager; Telecommunications consultant | 7h | 518 | 490 |
| 25 | 3.4.2 | Select & Order New PABX |  | 1h | 2018-05-23 09:30 | 2018-05-23 10:30 | 24 | 2011-04-19 14:00 | 2011-04-19 15:00 | 1h | 0.5d | 0d |  | Project Manager | 1h | 88 | 80 |

| ID | WBS | Task | Type | Duration | Start | Finish | Predecessors | Baseline start | Baseline finish | Baseline duration | Total slack | Free slack | Constraint | Resources | Work | Cost | Baseline cost |
| --- | --- | --- | --- | --- | --- | --- | --- | --- | --- | --- | --- | --- | --- | --- | --- | --- | --- |
| 26 | 3.5 | **IT Networking Consultations** |  | 6.79d | 2018-05-23 10:30 | 2018-05-31 17:00 |  | 2011-04-19 15:00 | 2011-05-03 12:30 | 6.79d | 0.5d |  |  |  | 16h | 21,324 | 21,280 |
| 27 | 3.5.1 | Design Network Access Points Map |  | 0.5d | 2018-05-23 10:30 | 2018-05-23 15:00 | 22, 25 | 2011-04-19 15:00 | 2011-04-20 10:30 | 0.5d | 0.5d | 0d |  | IT Consultant; Project Manager | 7h | 588 | 560 |
| 28 | 3.5.2 | Select & Order New PCs |  | 1h | 2018-05-23 15:00 | 2018-05-23 16:00 | 27 | 2011-04-20 10:30 | 2011-04-20 11:30 | 1h | 0.5d | 0d |  | Project Manager | 1h | 88 | 80 |
| 29 | 3.5.3 | New PCs Arrive |  | 1h | 2018-05-30 16:00 | 2018-05-30 17:00 | 28FS+5d | 2011-04-29 11:30 | 2011-04-29 12:30 | 1h | 0.5d | 0d |  | Project Manager | 1h | 20,088 | 20,080 |
| 30 | 3.5.4 | Configure SOE on PCs |  | 1d | 2018-05-31 09:00 | 2018-05-31 17:00 | 29 | 2011-04-29 12:30 | 2011-05-03 12:30 | 1d | 0.5d | 0d |  | IT Consultant | 7h | 560 | 560 |
| 31 | 3.6 | **Restructure Office** |  | 13d | 2018-05-23 06:00 | 2018-06-08 17:00 |  | 2011-04-20 06:00 | 2011-05-11 17:00 | 13d | 0.5d |  |  |  | 64.5h | 53,025 | 53,025 |
| 32 | 3.6.1 | Erect New Walls |  | 7h | 2018-05-23 06:00 | 2018-05-25 07:00 | 22 | 2011-04-20 06:00 | 2011-04-26 07:00 | 7h | 1d | 0d |  | Carpenter [200%] | 14h | 490 | 490 |
| 33 | 3.6.2 | Gyprock, Plaster & Finish |  | 14h | 2018-05-25 07:00 | 2018-05-29 08:00 | 32 | 2011-04-26 07:00 | 2011-04-30 10:00 | 14h | 1d |  |  | Plasterer | 14h | 10,490 | 10,490 |
| 34 | 3.6.3 | Install Network Points |  | 5h | 2018-06-01 09:00 | 2018-06-01 15:00 | 33FS+1ed, 30 | 2011-05-03 12:30 | 2011-05-04 10:30 | 5h | 0.5d | 0d |  | IT Consultant | 5h | 400 | 400 |
| 35 | 3.6.4 | Install Phone Connections |  | 0.5d | 2018-06-01 09:00 | 2018-06-01 12:30 | 34SS | 2011-05-03 12:30 | 2011-05-03 17:00 | 0.5d | 0.5d |  |  | Telecommunications consultant | 3.5h | 700 | 700 |
| 36 | 3.6.5 | Re-Paint |  | 1d | 2018-06-02 07:00 | 2018-06-02 15:00 | 35 | 2011-05-04 06:00 | 2011-05-06 07:00 | 1d | 0d |  |  | Paint [100 Litre]; Painter | 7h | 25,245 | 25,245 |
| 37 | 3.6.6 | Carpet |  | 1d | 2018-06-04 06:00 | 2018-06-06 07:00 | 36FS+1ed | 2011-05-07 07:00 | 2011-05-07 15:00 | 1d | 0d |  |  | Carpet [100 Lin Metre]; Carpet Contractor | 7h | 15,000 | 15,000 |
| 38 | 3.6.7 | Install New Furniture |  | 1d | 2018-06-06 07:00 | 2018-06-08 08:00 | 37 | 2011-05-09 06:00 | 2011-05-11 07:00 | 1d | 0d |  |  | Labourer | 7h | 140 | 140 |
| 39 | 3.6.8 | Install New PCs |  | 1d | 2018-06-08 09:00 | 2018-06-08 17:00 | 38 | 2011-05-11 09:00 | 2011-05-11 17:00 | 1d | 0.5d | 0d |  | IT Consultant | 7h | 560 | 560 |
| 40 | 3.6.9 | Refit Office Complete | milestone | 0d | 2018-06-08 17:00 | 2018-06-08 17:00 | 39 | 2011-05-11 17:00 | 2011-05-11 17:00 | 0d | 0.5d | 0d |  |  |  |  |  |
| 41 | 4 | **Office Move** |  | 10d | 2018-05-31 09:00 | 2018-06-14 07:00 |  | 2011-04-29 12:30 | 2011-05-16 17:00 | 10.5d | 0d |  |  |  | 221.5h | 11,036 | 11,028 |
| 42 | 4.1 | Order packing boxes |  | 1h | 2018-05-31 09:00 | 2018-05-31 10:00 | 29 | 2011-04-29 12:30 | 2011-04-29 14:30 | 1h | 7.36d | 6.86d |  | Project Manager | 1h | 88 | 80 |
| 43 | 4.2 | Staff Pack |  | 0.5d | 2018-06-11 09:00 | 2018-06-11 12:30 | 40, 42 | 2011-05-12 09:00 | 2011-05-12 12:30 | 0.5d | 0.5d | 0d |  | Project Manager; Staff [2000%] | 73.5h | 3,808 | 3,808 |
| 44 | 4.3 | Staff Move |  | 2d | 2018-06-11 12:30 | 2018-06-14 07:00 | 43 | 2011-05-12 12:30 | 2011-05-14 11:00 | 2d | 0d |  |  | Staff [2000%]; Labourer | 147h | 7,140 | 7,140 |
| 45 | 4.4 | Office Move Complete | milestone | 0d | 2018-06-14 07:00 | 2018-06-14 07:00 | 44 | 2011-05-16 17:00 | 2011-05-16 17:00 | 0d | 0d |  | finish no later than 2018-06-22 19:00 |  |  |  |  |
