# Earned Value

Schedule from MS Project, 2018-05-07 to 2018-08-09, costs in $.
Templates

## Calendars

- Standard: Mon-Fri 08:00-12:00, 13:00-17:00; Sat-Sun off.

## Resources

| Resource | Rate |
| --- | --- |
| Architect | 100 |
| Concrete subcontractor | 50 |
| Plumbing subcontractor | 50 |
| Carpenters | 50 |
| Labourers | 20 |
| Roofing subcontractor | 50 |
| Bricklayers | 50 |
| Electrician | 50 |
| Plasterer | 50 |
| Cabinetmaker | 50 |
| Plumber | 75 |
| Tiler | 50 |
| Painters | 20 |

## Schedule

| ID | Task | Type | Duration | Start | Finish | Predecessors | Total slack | Resources | Work | Cost |
| --- | --- | --- | --- | --- | --- | --- | --- | --- | --- | --- |
| 1 | Planning Stage |  | 6w | 2018-05-07 | 2018-06-15 |  | 0d | Architect | 240h | 24,000 |
| 2 | Footings |  | 3d | 2018-06-18 | 2018-06-20 | 1 | 0d | Concrete subcontractor | 24h | 1,200 |
| 3 | External Plumbing |  | 1d | 2018-06-21 | 2018-06-21 | 2 | 0d | Plumbing subcontractor | 8h | 400 |
| 4 | Pour foundation slab |  | 1d | 2018-06-22 | 2018-06-22 | 3 | 0d | Concrete subcontractor | 8h | 400 |
| 5 | Slab down | milestone | 0d | 2018-06-23 | 2018-06-23 | 4FS+24eh | 0d |  |  |  |
| 6 | Erect house frame |  | 5d | 2018-06-25 | 2018-06-29 | 5 | 0d | Carpenters [300%]; Labourers [200%] | 200h | 7,600 |
| 7 | Roofing tiles |  | 3d | 2018-07-02 | 2018-07-04 | 6 | 0d | Roofing subcontractor | 24h | 1,200 |
| 8 | Brick Walls |  | 5d | 2018-07-05 | 2018-07-11 | 7 | 0d | Bricklayers [300%] | 120h | 6,000 |
| 9 | Fit Windows & Doors |  | 2d | 2018-07-12 | 2018-07-13 | 8 | 0d | Carpenters | 16h | 800 |
| 10 | Electrical Cables |  | 1d | 2018-07-16 | 2018-07-16 | 9 | 0d | Electrician | 8h | 400 |
| 11 | Internal Plumbing |  | 1d | 2018-07-16 | 2018-07-16 | 10SS | 0d | Plumbing subcontractor | 8h | 400 |
| 12 | Plaster Walls |  | 5d | 2018-07-17 | 2018-07-23 | 11 | 0d | Plasterer | 40h | 2,000 |
| 13 | Internal Doors and Trim |  | 4d | 2018-07-24 | 2018-07-27 | 12 | 0d | Carpenters | 32h | 1,600 |
| 14 | Install Kitchen |  | 2d | 2018-07-30 | 2018-07-31 | 13 | 0d | Cabinetmaker [200%]; Plumber | 48h | 2,800 |
| 15 | Install Bathroom |  | 2d | 2018-07-30 | 2018-07-31 | 14SS | 0d | Plumber; Tiler | 32h | 2,000 |
| 16 | Final Electrical Fittings |  | 2d | 2018-08-01 | 2018-08-02 | 15 | 0d | Electrician | 16h | 800 |
| 17 | Final Plumbing Fittings |  | 2d | 2018-08-01 | 2018-08-02 | 16SS | 0d | Plumber | 16h | 1,200 |
| 18 | Paint |  | 5d | 2018-08-03 | 2018-08-09 | 17 | 0d | Painters [200%] | 80h | 1,600 |
| 19 | Lock up | milestone | 0d | 2018-08-09 | 2018-08-09 | 18 | 0d |  |  |  |
