# CKM Office Renovation

Schedule from MS Project, 2018-05-07 to 2018-06-21, 7 hours a day, costs in $, A marks actual dates.
Office Renovation Project
Corporate Knowledge Management

## Calendars

- Standard: Mon-Fri 09:00-13:00, 14:00-17:00; Sat-Sun off.

## Resources

| Resource | Group | Unit | Rate | Cost per use |
| --- | --- | --- | --- | --- |
| Carpenter | Contractor |  | 35 |  |
| Carpet | Materials | Lin Metre | 100 |  |
| Carpet Contractor | Contractor |  |  |  |
| Fit-out Consultant | Consultant |  | 65 | 50 |
| Furniture | Asset |  |  |  |
| Gyprock | Material | Sheet | 30 |  |
| Plaster | Material | Bag | 50 |  |
| IT Consultant | Contractor |  | 80 |  |
| Labourer | Contractor |  | 20 |  |
| Management | Staff |  | 100 |  |
| Network Cable & Points | Asset |  |  |  |
| PABX & Points | Asset |  |  |  |
| Paint | Material | Litre | 250 |  |
| Painter | Contractor |  | 35 |  |
| Personal Computers | Asset |  |  |  |
| Phones | Asset |  |  |  |
| Plasterer | Contractor |  | 35 |  |
| Project Manager | Staff |  | 80 |  |
| Staff | Staff |  | 50 |  |
| Telecommunications consultant | Consultant |  | 60 |  |
| Admin Assistant | Staff |  | 45 |  |

## Schedule

| ID | WBS | Task | Type | Duration | Start | Finish | Predecessors | Complete | Baseline start | Baseline finish | Baseline duration | Deadline | Resources | Work | Actual work | Cost | Baseline cost | Actual cost |
| --- | --- | --- | --- | --- | --- | --- | --- | --- | --- | --- | --- | --- | --- | --- | --- | --- | --- | --- |
| 1 | 1 | **Planning & Research** |  | 8.43d | 2018-05-07 09:00 A | 2018-05-17 12:00 A |  | 100% | 2018-05-07 09:00 | 2018-05-17 12:00 | 8.43d |  |  | 24h | 24h | 2,112 | 2,112 | 2,112 |
| 2 | 1.1 | Develop Requirements Documentation |  | 1d | 2018-05-07 09:00 A | 2018-05-07 17:00 A |  | 100% | 2018-05-07 09:00 | 2018-05-07 17:00 | 1d | 2018-05-07 17:00 | Project Manager | 7h | 7h | 616 | 616 | 616 |
| 3 | 1.2 | Fit-Out Consultant Research |  | 0.5d | 2018-05-08 09:00 A | 2018-05-08 12:30 A | 2 | 100% | 2018-05-08 09:00 | 2018-05-08 12:30 | 0.5d |  | Project Manager | 3.5h | 3.5h | 308 | 308 | 308 |
| 4 | 1.3 | Telecommunications Consultant Research |  | 0.5d | 2018-05-08 12:30 A | 2018-05-08 17:00 A | 3 | 100% | 2018-05-08 12:30 | 2018-05-08 17:00 | 0.5d |  | Project Manager | 3.5h | 3.5h | 308 | 308 | 308 |
| 5 | 1.4 | IT Network Contractor Research |  | 0.5d | 2018-05-09 09:00 A | 2018-05-09 12:30 A | 4 | 100% | 2018-05-09 09:00 | 2018-05-09 12:30 | 0.5d |  | Project Manager | 3.5h | 3.5h | 308 | 308 | 308 |
| 6 | 1.5 | Building Contractors Research |  | 0.5d | 2018-05-09 12:30 A | 2018-05-09 17:00 A | 5 | 100% | 2018-05-09 12:30 | 2018-05-09 17:00 | 0.5d |  | Project Manager | 3.5h | 3.5h | 308 | 308 | 308 |
| 7 | 1.6 | Submit Requirements to Resources & Request Quotes |  | 2h | 2018-05-10 09:00 A | 2018-05-10 11:00 A | 6 | 100% | 2018-05-10 09:00 | 2018-05-10 11:00 | 2h |  | Project Manager | 2h | 2h | 176 | 176 | 176 |
| 8 | 1.7 | Quotes Received |  | 1h | 2018-05-17 11:00 A | 2018-05-17 12:00 A | 7FS+5d | 100% | 2018-05-17 11:00 | 2018-05-17 12:00 | 1h |  | Project Manager | 1h | 1h | 88 | 88 | 88 |
| 9 | 1.8 | Planning & Research Complete | milestone | 0d | 2018-05-17 12:00 A | 2018-05-17 12:00 A | 8 | 100% | 2018-05-17 12:00 | 2018-05-17 12:00 | 0d |  |  |  |  |  |  |  |
| 10 | 2 | **Management Approval** |  | 1.79d | 2018-05-17 12:00 A | 2018-05-21 10:30 A |  | 100% | 2018-05-17 12:00 | 2018-05-21 10:30 | 1.79d |  |  | 13.5h | 13.5h | 1,200 | 1,200 | 1,200 |
| 11 | 2.1 | Consolidate Quotes and develop proposal |  | 1.5d | 2018-05-17 12:00 A | 2018-05-18 16:30 A | 9 | 100% | 2018-05-17 12:00 | 2018-05-18 16:30 | 1.5d |  | Project Manager | 10.5h | 10.5h | 924 | 924 | 924 |
| 12 | 2.2 | Develop Project Plan & Durations |  | 1h | 2018-05-18 16:30 A | 2018-05-21 09:30 A | 11 | 100% | 2018-05-18 16:30 | 2018-05-21 09:30 | 1h |  | Project Manager | 1h | 1h | 88 | 88 | 88 |
| 13 | 2.3 | Submit Project Plan & Costs to Management |  | 1h | 2018-05-21 09:30 A | 2018-05-21 10:30 A | 12 | 100% | 2018-05-21 09:30 | 2018-05-21 10:30 | 1h |  | Project Manager; Management | 2h | 2h | 188 | 188 | 188 |
| 14 | 2.4 | Management Approval Received | milestone | 0d | 2018-05-21 10:30 A | 2018-05-21 10:30 A | 13 | 100% | 2018-05-21 10:30 | 2018-05-21 10:30 | 0d |  |  |  |  |  |  |  |
| 15 | 3 | **Refit Office** |  | 19.79d | 2018-05-21 10:30 A | 2018-06-18 09:00 A |  | 100% | 2018-05-21 10:30 | 2018-06-18 09:00 | 19.79d |  |  | 111.5h | 111.5h | 76,763.5 | 76,763.5 | 76,763.5 |
| 16 | 3.1 | Appoint Resources |  | 2h | 2018-05-21 10:30 A | 2018-05-21 12:30 A | 14 | 100% | 2018-05-21 10:30 | 2018-05-21 12:30 | 2h |  | Project Manager | 2h | 2h | 176 | 176 | 176 |
| 17 | 3.2 | Staff Briefing |  | 1h | 2018-05-21 12:30 A | 2018-05-21 14:30 A | 16 | 100% | 2018-05-21 12:30 | 2018-05-21 14:30 | 1h |  | Project Manager; Staff [700%] | 8h | 8h | 438 | 438 | 438 |
| 18 | 3.3 | **Fit-Out Consultations** |  | 0.93d | 2018-05-21 14:30 A | 2018-05-22 13:00 A |  | 100% | 2018-05-21 14:30 | 2018-05-22 13:00 | 0.93d |  |  | 13h | 13h | 1,194.5 | 1,194.5 | 1,194.5 |
| 19 | 3.3.1 | Office Space / Structure Plan |  | 0.5d | 2018-05-21 14:30 A | 2018-05-22 10:00 A | 17 | 100% | 2018-05-21 14:30 | 2018-05-22 10:00 | 0.5d |  | Fit-out Consultant; Project Manager | 7h | 7h | 585.5 | 585.5 | 585.5 |
| 20 | 3.3.2 | Select & Order Carpet |  | 1h | 2018-05-22 10:00 A | 2018-05-22 11:00 A | 19 | 100% | 2018-05-22 10:00 | 2018-05-22 11:00 | 1h |  | Fit-out Consultant; Project Manager | 2h | 2h | 203 | 203 | 203 |
| 21 | 3.3.3 | Select & Order Paint |  | 1h | 2018-05-22 11:00 A | 2018-05-22 12:00 A | 20 | 100% | 2018-05-22 11:00 | 2018-05-22 12:00 | 1h |  | Fit-out Consultant; Project Manager | 2h | 2h | 203 | 203 | 203 |
| 22 | 3.3.4 | Select & Order Office Furniture |  | 1h | 2018-05-22 12:00 A | 2018-05-22 13:00 A | 21 | 100% | 2018-05-22 12:00 | 2018-05-22 13:00 | 1h |  | Fit-out Consultant; Project Manager | 2h | 2h | 203 | 203 | 203 |
| 23 | 3.4 | **Telecommuncations Consultations** |  | 0.64d | 2018-05-22 14:00 A | 2018-05-23 10:30 A |  | 100% | 2018-05-22 14:00 | 2018-05-23 10:30 | 0.64d |  |  | 8h | 8h | 606 | 606 | 606 |
| 24 | 3.4.1 | Design Telephone Access Points Map |  | 0.5d | 2018-05-22 14:00 A | 2018-05-23 09:30 A | 22 | 100% | 2018-05-22 14:00 | 2018-05-23 09:30 | 0.5d |  | Project Manager; Telecommunications consultant | 7h | 7h | 518 | 518 | 518 |
| 25 | 3.4.2 | Select & Order New PABX |  | 1h | 2018-05-23 09:30 A | 2018-05-23 10:30 A | 24 | 100% | 2018-05-23 09:30 | 2018-05-23 10:30 | 1h |  | Project Manager | 1h | 1h | 88 | 88 | 88 |

| ID | WBS | Task | Type | Duration | Start | Finish | Predecessors | Complete | Baseline start | Baseline finish | Baseline duration | Total slack | Free slack | Constraint | Resources | Work | Actual work | Cost | Baseline cost | Actual cost |
| --- | --- | --- | --- | --- | --- | --- | --- | --- | --- | --- | --- | --- | --- | --- | --- | --- | --- | --- | --- | --- |
| 26 | 3.5 | **IT Networking Consultations** |  | 9.79d | 2018-05-23 10:30 A | 2018-06-05 17:00 A |  | 100% | 2018-05-23 10:30 | 2018-06-05 17:00 | 9.79d |  |  |  |  | 16h | 16h | 21,324 | 21,324 | 21,324 |
| 27 | 3.5.1 | Design Network Access Points Map |  | 0.5d | 2018-05-23 10:30 A | 2018-05-23 15:00 A | 22, 25 | 100% | 2018-05-23 10:30 | 2018-05-23 15:00 | 0.5d |  |  |  | IT Consultant; Project Manager | 7h | 7h | 588 | 588 | 588 |
| 28 | 3.5.2 | Select & Order New PCs |  | 1h | 2018-05-23 15:00 A | 2018-05-23 16:00 A | 27 | 100% | 2018-05-23 15:00 | 2018-05-23 16:00 | 1h |  |  |  | Project Manager | 1h | 1h | 88 | 88 | 88 |
| 29 | 3.5.3 | New PCs Arrive |  | 1h | 2018-06-01 16:00 A | 2018-06-01 17:00 A | 28FS+5d | 100% | 2018-06-01 16:00 | 2018-06-01 17:00 | 1h |  |  |  | Project Manager | 1h | 1h | 20,088 | 20,088 | 20,088 |
| 30 | 3.5.4 | Configure SOE on PCs |  | 1d | 2018-06-05 09:00 A | 2018-06-05 17:00 A | 29 | 100% | 2018-06-05 09:00 | 2018-06-05 17:00 | 1d |  |  |  | IT Consultant | 7h | 7h | 560 | 560 | 560 |
| 31 | 3.6 | **Restructure Office** |  | 18d | 2018-05-23 09:00 A | 2018-06-18 09:00 A |  | 100% | 2018-05-23 09:00 | 2018-06-18 09:00 | 18d |  |  |  |  | 64.5h | 64.5h | 53,025 | 53,025 | 53,025 |
| 32 | 3.6.1 | Erect New Walls |  | 7h | 2018-05-23 09:00 A | 2018-05-26 08:00 A | 22 | 100% | 2018-05-23 09:00 | 2018-05-26 08:00 | 7h |  |  |  | Carpenter [200%] | 14h | 14h | 490 | 490 | 490 |
| 33 | 3.6.2 | Gyprock, Plaster & Finish |  | 14h | 2018-05-29 09:00 A | 2018-06-02 13:00 A | 32 | 100% | 2018-05-29 09:00 | 2018-06-02 13:00 | 14h |  |  |  | Plasterer | 14h | 14h | 10,490 | 10,490 | 10,490 |
| 34 | 3.6.3 | Install Network Points |  | 5h | 2018-06-06 09:00 A | 2018-06-06 15:00 A | 33FS+1ed, 30 | 100% | 2018-06-06 09:00 | 2018-06-06 15:00 | 5h |  |  |  | IT Consultant | 5h | 5h | 400 | 400 | 400 |
| 35 | 3.6.4 | Install Phone Connections |  | 0.5d | 2018-06-06 09:00 A | 2018-06-06 12:30 A | 34SS | 100% | 2018-06-06 09:00 | 2018-06-06 12:30 | 0.5d |  |  |  | Telecommunications consultant | 3.5h | 3.5h | 700 | 700 | 700 |
| 36 | 3.6.5 | Re-Paint |  | 1d | 2018-06-07 09:00 A | 2018-06-09 11:00 A | 35 | 100% | 2018-06-07 09:00 | 2018-06-09 11:00 | 1d |  |  |  | Paint [100 Litre]; Painter | 7h | 7h | 25,245 | 25,245 | 25,245 |
| 37 | 3.6.6 | Carpet |  | 1d | 2018-06-11 09:00 A | 2018-06-14 07:00 A | 36FS+1ed | 100% | 2018-06-11 09:00 | 2018-06-14 07:00 | 1d |  |  |  | Carpet [100 Lin Metre]; Carpet Contractor | 7h | 7h | 15,000 | 15,000 | 15,000 |
| 38 | 3.6.7 | Install New Furniture |  | 1d | 2018-06-13 09:00 A | 2018-06-16 08:00 A | 37 | 100% | 2018-06-13 09:00 | 2018-06-16 08:00 | 1d |  |  |  | Labourer | 7h | 7h | 140 | 140 | 140 |
| 39 | 3.6.8 | Install New PCs |  | 1d | 2018-06-15 09:00 A | 2018-06-15 17:00 A | 38 | 100% | 2018-06-15 09:00 | 2018-06-15 17:00 | 1d |  |  |  | IT Consultant | 7h | 7h | 560 | 560 | 560 |
| 40 | 3.6.9 | Refit Office Complete | milestone | 0d | 2018-06-18 09:00 A | 2018-06-18 09:00 A | 39 | 100% | 2018-06-18 09:00 | 2018-06-18 09:00 | 0d |  |  |  |  |  |  |  |  |  |
| 41 | 4 | **Office Move** |  | 13d | 2018-06-04 09:00 | 2018-06-21 07:00 |  |  | 2018-06-04 09:00 | 2018-06-21 07:00 | 13d | 0d |  |  |  | 221.5h |  | 11,036 | 11,036 |  |
| 42 | 4.1 | Order packing boxes |  | 1h | 2018-06-04 09:00 | 2018-06-04 10:00 | 29 |  | 2018-06-04 09:00 | 2018-06-04 10:00 | 1h | 10.36d | 9.86d |  | Project Manager | 1h |  | 88 | 88 |  |
| 43 | 4.2 | Staff Pack |  | 0.5d | 2018-06-18 09:00 | 2018-06-18 12:30 | 40, 42 |  | 2018-06-18 09:00 | 2018-06-18 12:30 | 0.5d | 0.5d | 0d |  | Project Manager; Staff [2000%] | 73.5h |  | 3,808 | 3,808 |  |
| 44 | 4.3 | Staff Move |  | 2d | 2018-06-18 12:30 | 2018-06-21 07:00 | 43 |  | 2018-06-18 12:30 | 2018-06-21 07:00 | 2d | 0d |  |  | Staff [2000%]; Labourer | 147h |  | 7,140 | 7,140 |  |
| 45 | 4.4 | Office Move Complete | milestone | 0d | 2018-06-21 07:00 | 2018-06-21 07:00 | 44 |  | 2018-06-21 07:00 | 2018-06-21 07:00 | 0d | 0d |  | finish no later than 2018-06-22 19:00 |  |  |  |  |  |  |
