# Construction Project

Schedule from MS Project, 2018-05-07 to 2018-08-25.
Complete Knowledge Management

## Calendars

- Standard: Mon-Fri 08:00-12:30, 13:30-17:00; Sat-Sun off.

## Resources

| Resource | Group | Unit | Rate | Notes |
| --- | --- | --- | --- | --- |
| Designer | Internal |  |  | Designer is unavailable until 5 April. |
| Drafter | Internal |  |  |  |
| Accountant | Internal |  |  |  |
| Admin Assistant | Internal |  |  |  |
| Supervisor | Internal |  |  |  |
| Labourer | Internal |  |  |  |
| Equipment Operators | Internal |  |  |  |
| Drivers | Internal |  |  |  |
| Riggers | Internal |  |  |  |
| Welders | Internal |  |  |  |
| Boilermakers | Internal |  |  |  |
| Trade Assistants | Internal |  |  |  |
| Electrician | External Hire |  |  |  |
| Plumbers | External hire |  |  |  |
| Testers | Subcontractor |  |  |  |
| Building Inspector | External |  |  |  |
| Concreting Subcontractor | Subcontractor |  |  |  |
| Crane Hire Subcontractor | Subcontractor |  |  |  |
| Bulldozer | Equipment |  |  |  |
| Semitrailer | Equipment |  |  |  |
| Digger | Equipment |  |  |  |
| Fuel | Consumable | litre | 1.5 |  |

## Schedule

| ID | WBS | Task | Type | Duration | Start | Finish | Predecessors | Total slack | Free slack | Resources | Work |
| --- | --- | --- | --- | --- | --- | --- | --- | --- | --- | --- | --- |
| 1 | 1 | **Planning** |  | 21d | 2018-05-07 | 2018-06-04 |  | 5d |  |  | 270.6h |
| 2 | 1.1 | Design Plans |  | 2w | 2018-05-07 | 2018-05-18 |  | 5d | 0d | Designer; Drafter [200%] | 240h |
| 3 | 1.2 | Cost Estimation |  | 1d | 2018-05-21 | 2018-05-21 | 2 | 5d | 0d | Designer; Drafter [50%]; Accountant [20%] | 13.6h |
| 4 | 1.3 | Apply for loans |  | 2w | 2018-05-22 | 2018-06-04 | 3 | 57d | 0d | Accountant [75%] | 10h |
| 5 | 1.4 | Apply for permits |  | 2w | 2018-05-22 | 2018-06-04 | 3 | 5d | 0d | Drafter [37.5%]; Designer [50%] | 7h |
| 6 | 1.5 | Planning complete | milestone | 0d | 2018-06-04 | 2018-06-04 | 5 | 59d |  |  |  |
| 7 | 2 | **Site Preparation** |  | 7d | 2018-06-05 | 2018-06-13 |  | 5d |  |  | 408h |
| 8 | 2.1 | Order materials |  | 2d | 2018-06-05 | 2018-06-06 | 5, 4 | 57d |  | Drafter; Admin Assistant | 32h |
| 9 | 2.2 | Site preparation |  | 1w | 2018-06-05 | 2018-06-11 | 5 | 5d | 0d | Labourer [400%]; Supervisor; Equipment Operators; Bulldozer | 280h |
| 10 | 2.3 | Delivery of materials to site |  | 2d | 2018-06-12 | 2018-06-13 | 9 | 52d | 0d | Drafter; Admin Assistant; Drivers [200%]; Semitrailer [200%] | 96h |
| 11 | 2.4 | Site Prep finalised | milestone | 0d | 2018-06-13 | 2018-06-13 | 10 | 52d |  |  |  |
| 12 | 3 | **Foundation** |  | 9.75d | 2018-06-12 | 2018-06-25 |  | 5d |  |  | 504h |
| 13 | 3.1 | Dig footings |  | 1w | 2018-06-12 | 2018-06-18 | 9 | 5d | 0d | Supervisor; Labourer [400%]; Equipment Operators; Digger | 280h |
| 14 | 3.2 | Pour concrete |  | 3d | 2018-06-15 | 2018-06-20 | 13FS-2.5% | 5d | 0d | Concreting Subcontractor | 24h |
| 15 | 3.3 | Dig drainage trenches |  | 1w | 2018-06-18 | 2018-06-25 | 14FS-2d | 42.25d | 0d | Supervisor; Labourer [200%]; Equipment Operators; Bulldozer | 200h |
| 16 | 3.4 | Foundations completed | milestone | 0d | 2018-06-25 | 2018-06-25 | 14, 15 | 44.25d |  |  |  |
| 17 | 4 | **Building & Construction** |  | 39d | 2018-06-22 | 2018-08-16 |  | 5d |  |  | 3384h |
| 18 | 4.1 | Pour Concrete in trenches |  | 2d | 2018-06-25 | 2018-06-27 | 15 | 42.25d | 36d | Concreting Subcontractor | 16h |
| 19 | 4.2 | Pile Driving |  | 3w | 2018-06-22 | 2018-07-13 | 14FS+48eh | 5d | 0d | Supervisor; Riggers [400%]; Welders [200%]; Boilermakers [200%]; Trade Assistants [800%] | 2040h |
| 20 | 4.3 | Erect upper level gantry and platform |  | 1w | 2018-07-13 | 2018-07-20 | 19 | 5d | 0d | Supervisor; Riggers [200%]; Welders; Boilermakers; Trade Assistants [400%] | 360h |
| 21 | 4.4 | Install Elevator |  | 1w | 2018-07-20 | 2018-07-27 | 20 | 20.25d | 14d | Supervisor; Electrician; Riggers [200%]; Welders | 200h |
| 22 | 4.5 | Install Electrical wiring |  | 1w | 2018-07-20 | 2018-07-27 | 20 | 5d | 0d | Electrician | 40h |
| 23 | 4.6 | Test Elevator and related systems |  | 2d | 2018-07-27 | 2018-07-31 | 22 | 17.25d | 0d | Supervisor; Electrician; Riggers | 48h |
| 24 | 4.7 | Approvals for Elevator systems |  | 1d | 2018-07-31 | 2018-08-01 | 23 | 17.25d | 11d | Supervisor; Admin Assistant; Building Inspector | 24h |
| 25 | 4.8 | Installation of upper gantry winch |  | 1w | 2018-07-20 | 2018-07-27 | 22SS | 5d | 0d | Supervisor; Electrician; Riggers; Crane Hire Subcontractor | 160h |
| 26 | 4.9 | Installation of drainage pump |  | 1w | 2018-07-27 | 2018-08-03 | 22 | 15.25d | 9d | Plumbers [200%] | 80h |
| 27 | 4.10 | Fit Bungy cords |  | 3d | 2018-07-27 | 2018-08-01 | 25 | 5d | 0d | Supervisor; Riggers; Trade Assistants | 72h |
| 28 | 4.11 | Test Bungy capacities |  | 1.6w | 2018-08-01 | 2018-08-15 | 27 | 5d | 0d | Testers [400%] | 320h |
| 29 | 4.12 | Final Inspections |  | 1d | 2018-08-15 | 2018-08-16 | 28 | 5d | 0d | Supervisor; Admin Assistant; Building Inspector | 24h |
| 30 | 4.13 | Construction completed | milestone | 0d | 2018-08-16 | 2018-08-16 | 18, 21, 23, 24, 26, 29 | 6.25d |  |  |  |

| ID | WBS | Task | Type | Duration | Start | Finish | Predecessors | Total slack | Free slack | Constraint | Resources | Work |
| --- | --- | --- | --- | --- | --- | --- | --- | --- | --- | --- | --- | --- |
| 31 | 5 | **Open Day** |  | 7d | 2018-08-16 | 2018-08-25 |  | 0d |  |  |  | 18h |
| 32 | 5.1 | Invite guests to Open Day |  | 2d | 2018-08-16 | 2018-08-17 | 29FS-7.5% | 5d | 0d |  | Admin Assistant | 16h |
| 33 | 5.2 | Invite political guests to opening |  | 2h | 2018-08-17 | 2018-08-17 | 32FF | 5d |  |  | Admin Assistant | 2h |
| 34 | 5.3 | Open Day | milestone | 13eh | 2018-08-25 | 2018-08-25 | 33, 32 | 0d |  | must start on 2018-08-25 |  |  |
