# Project A

Schedule from MS Project, 2018-05-07 to 2018-08-02.
Templates

## Calendars

- Standard: Mon-Fri 08:00-12:00, 13:00-17:00; Sat-Sun off.

## Schedule

| ID | Task | Duration | Start | Finish | Predecessors | Total slack |
| --- | --- | --- | --- | --- | --- | --- |
| 1 | Architectural Plans | 2w | 2018-05-07 | 2018-05-18 |  | 0d |
| 2 | Council approval | 1d | 2018-05-21 | 2018-05-21 | 1 | 0d |
| 3 | Site preparation | 3d | 2018-06-11 | 2018-06-13 | 2FS+14d | 0d |
| 4 | Delivery of Materials | 1d | 2018-06-11 | 2018-06-11 | 3SS | 38d |
| 5 | Lay Foundations | 2d | 2018-06-14 | 2018-06-15 | 3 | 0d |
| 6 | External Plumbing | 1d | 2018-06-18 | 2018-06-18 | 5 | 0d |
| 7 | Pour foundation slab | 1d | 2018-06-19 | 2018-06-19 | 6 | 0d |
| 8 | Erect house frame | 3d | 2018-06-20 | 2018-06-22 | 7 | 0d |
| 9 | Roofing tiles | 3d | 2018-06-25 | 2018-06-27 | 8 | 0d |
| 10 | Brick Walls | 5d | 2018-06-28 | 2018-07-04 | 9 | 0d |
| 11 | Fit Windows & Doors | 2d | 2018-07-05 | 2018-07-06 | 10 | 0d |
| 12 | Electrical Cables | 1d | 2018-07-09 | 2018-07-09 | 11 | 0d |
| 13 | Internal Plumbing | 1d | 2018-07-09 | 2018-07-09 | 12SS | 0d |
| 14 | Plaster Walls | 5d | 2018-07-10 | 2018-07-16 | 13 | 0d |
| 15 | Internal Doors and Trim | 4d | 2018-07-17 | 2018-07-20 | 14 | 0d |
| 16 | Install Kitchen | 2d | 2018-07-23 | 2018-07-24 | 15 | 0d |
| 17 | Install Bathroom | 2d | 2018-07-23 | 2018-07-24 | 16SS | 0d |
| 18 | Final Electrical Fittings | 2d | 2018-07-25 | 2018-07-26 | 17 | 0d |
| 19 | Final Plumbing Fittings | 2d | 2018-07-25 | 2018-07-26 | 18SS | 0d |
| 20 | Paint | 5d | 2018-07-27 | 2018-08-02 | 19 | 0d |
