# CKM Office Renovation

Schedule from MS Project, 2018-05-07 to 2018-05-29, 7 hours a day, costs in $.
Office Renovation Project
Corporate Knowledge Management

## Calendars

- Standard: Mon-Fri 09:00-13:00, 14:00-17:00; Sat-Sun off.

## Resources

| Resource | Group | Unit | Rate | Cost per use |
| --- | --- | --- | --- | --- |
| Carpenter | Contractor |  | 35 |  |
| Carpet | Materials | Lin Metre | 100 |  |
| Carpet Contractor | Contractor |  |  |  |
| Fit-out Consultant | Consultant |  | 65 | 50 |
| Furniture | Asset |  |  |  |
| Gyprock | Material | Sheet | 30 |  |
| Plaster | Material | Bag | 50 |  |
| IT Consultant | Contractor |  | 80 |  |
| Labourer | Contractor |  | 20 |  |
| Management | Staff |  | 100 |  |
| Network Cable & Points | Asset |  |  |  |
| PABX & Points | Asset |  |  |  |
| Paint | Material | Litre | 250 |  |
| Painter | Contractor |  | 35 |  |
| Personal Computers | Asset |  |  |  |
| Phones | Asset |  |  |  |
| Plasterer | Contractor |  | 35 |  |
| Project Manager | Staff |  | 80 |  |
| Staff | Staff |  | 50 |  |
| Telecommunications consultant | Consultant |  | 60 |  |
| Admin Assistant | Staff |  | 45 |  |

## Schedule

| ID | WBS | Task | Type | Duration | Start | Finish | Predecessors | Baseline start | Baseline finish | Baseline duration | Total slack | Free slack | Resources | Work | Cost | Baseline cost |
| --- | --- | --- | --- | --- | --- | --- | --- | --- | --- | --- | --- | --- | --- | --- | --- | --- |
| 1 | 1 | **Refit Office** |  | 17d | 2018-05-07 09:00 | 2018-05-29 17:00 |  | 2011-04-15 15:00 | 2011-05-11 17:00 | 15.29d | 0d |  |  | 125.5h | 77,817 | 76,607.5 |
| 2 | 1.1 | Appoint Resources |  | 2h | 2018-05-07 09:00 | 2018-05-07 11:00 |  | 2011-04-15 15:00 | 2011-04-15 17:00 | 2h | 0.71d | 0d | Project Manager | 2h | 176 | 160 |
| 3 | 1.2 | Staff Briefing |  | 1h | 2018-05-07 11:00 | 2018-05-07 12:00 | 2 | 2011-04-18 09:00 | 2011-04-18 10:00 | 1h | 0.71d | 0d | Project Manager; Staff [700%] | 8h | 438 | 430 |
| 4 | 1.3 | **Fit-Out Consultations** |  | 1.43d | 2018-05-07 12:00 | 2018-05-08 16:00 |  | 2011-04-18 10:00 | 2011-04-19 09:30 | 0.93d | 0.71d |  |  | 20h | 1,730 | 1,142.5 |
| 5 | 1.3.1 | Office Space / Structure Plan |  | 1d | 2018-05-07 12:00 | 2018-05-08 12:00 | 3 | 2011-04-18 10:00 | 2011-04-18 14:30 | 0.5d | 0.71d | 0d | Fit-out Consultant; Project Manager | 14h | 1,121 | 557.5 |
| 6 | 1.3.2 | Select & Order Carpet |  | 1h | 2018-05-08 12:00 | 2018-05-08 13:00 | 5 | 2011-04-18 14:30 | 2011-04-18 15:30 | 1h | 0.71d | 0d | Fit-out Consultant; Project Manager | 2h | 203 | 195 |
| 7 | 1.3.3 | Select & Order Paint |  | 1h | 2018-05-08 14:00 | 2018-05-08 15:00 | 6 | 2011-04-18 15:30 | 2011-04-18 16:30 | 1h | 0.71d | 0d | Fit-out Consultant; Project Manager | 2h | 203 | 195 |
| 8 | 1.3.4 | Select & Order Office Furniture |  | 1h | 2018-05-08 15:00 | 2018-05-08 16:00 | 7 | 2011-04-18 16:30 | 2011-04-19 09:30 | 1h | 0.71d | 0d | Fit-out Consultant; Project Manager | 2h | 203 | 195 |
| 9 | 1.4 | **Telecommuncations Consultations** |  | 1.14d | 2018-05-08 16:00 | 2018-05-09 17:00 |  | 2011-04-19 09:30 | 2011-04-19 15:00 | 0.64d | 0.71d |  |  | 15h | 1,124 | 570 |
| 10 | 1.4.1 | Design Telephone Access Points Map |  | 1d | 2018-05-08 16:00 | 2018-05-09 16:00 | 8 | 2011-04-19 09:30 | 2011-04-19 13:00 | 0.5d | 0.71d | 0d | Project Manager; Telecommunications consultant | 14h | 1,036 | 490 |
| 11 | 1.4.2 | Select & Order New PABX |  | 1h | 2018-05-09 16:00 | 2018-05-09 17:00 | 10 | 2011-04-19 14:00 | 2011-04-19 15:00 | 1h | 0.71d | 0d | Project Manager | 1h | 88 | 80 |
| 12 | 1.5 | **IT Networking Consultations** |  | 6.79d | 2018-05-10 09:00 | 2018-05-18 15:30 |  | 2011-04-19 15:00 | 2011-05-03 12:30 | 6.79d | 0.71d |  |  | 16h | 21,324 | 21,280 |
| 13 | 1.5.1 | Design Network Access Points Map |  | 0.5d | 2018-05-10 09:00 | 2018-05-10 12:30 | 8, 11 | 2011-04-19 15:00 | 2011-04-20 10:30 | 0.5d | 0.71d | 0d | IT Consultant; Project Manager | 7h | 588 | 560 |
| 14 | 1.5.2 | Select & Order New PCs |  | 1h | 2018-05-10 12:30 | 2018-05-10 14:30 | 13 | 2011-04-20 10:30 | 2011-04-20 11:30 | 1h | 0.71d | 0d | Project Manager | 1h | 88 | 80 |
| 15 | 1.5.3 | New PCs Arrive |  | 1h | 2018-05-17 14:30 | 2018-05-17 15:30 | 14FS+5d | 2011-04-29 11:30 | 2011-04-29 12:30 | 1h | 0.71d | 0d | Project Manager | 1h | 20,088 | 20,080 |
| 16 | 1.5.4 | Configure SOE on PCs |  | 1d | 2018-05-17 15:30 | 2018-05-18 15:30 | 15 | 2011-04-29 12:30 | 2011-05-03 12:30 | 1d | 0.71d | 0d | IT Consultant | 7h | 560 | 560 |
| 17 | 1.6 | **Restructure Office** |  | 15d | 2018-05-09 06:00 | 2018-05-29 17:00 |  | 2011-04-20 06:00 | 2011-05-11 17:00 | 13d | 0d |  |  | 64.5h | 53,025 | 53,025 |
| 18 | 1.6.1 | Erect New Walls |  | 7h | 2018-05-09 06:00 | 2018-05-11 07:00 | 8 | 2011-04-20 06:00 | 2011-04-26 07:00 | 7h | 3d | 0d | Carpenter [200%] | 14h | 490 | 490 |
| 19 | 1.6.2 | Gyprock, Plaster & Finish |  | 14h | 2018-05-11 07:00 | 2018-05-15 08:00 | 18 | 2011-04-26 07:00 | 2011-04-30 10:00 | 14h | 3d | 2.79d | Plasterer | 14h | 10,490 | 10,490 |
| 20 | 1.6.3 | Install Network Points |  | 5h | 2018-05-18 15:30 | 2018-05-21 12:30 | 19FS+1ed, 16 | 2011-05-03 12:30 | 2011-05-04 10:30 | 5h | 0.71d | 0d | IT Consultant | 5h | 400 | 400 |
| 21 | 1.6.4 | Install Phone Connections |  | 0.5d | 2018-05-18 15:30 | 2018-05-21 11:00 | 20SS | 2011-05-03 12:30 | 2011-05-03 17:00 | 0.5d | 0.71d |  | Telecommunications consultant | 3.5h | 700 | 700 |
| 22 | 1.6.5 | Re-Paint |  | 1d | 2018-05-22 06:00 | 2018-05-24 07:00 | 21 | 2011-05-04 06:00 | 2011-05-06 07:00 | 1d | 0d |  | Paint [100 Litre]; Painter | 7h | 25,245 | 25,245 |
| 23 | 1.6.6 | Carpet |  | 1d | 2018-05-25 07:00 | 2018-05-26 13:00 | 22FS+1ed | 2011-05-07 07:00 | 2011-05-07 15:00 | 1d | 0d |  | Carpet [100 Lin Metre]; Carpet Contractor | 7h | 15,000 | 15,000 |
| 24 | 1.6.7 | Install New Furniture |  | 1d | 2018-05-26 13:00 | 2018-05-29 08:00 | 23 | 2011-05-09 06:00 | 2011-05-11 07:00 | 1d | 0d |  | Labourer | 7h | 140 | 140 |
| 25 | 1.6.8 | Install New PCs |  | 1d | 2018-05-29 09:00 | 2018-05-29 17:00 | 24 | 2011-05-11 09:00 | 2011-05-11 17:00 | 1d | 0d |  | IT Consultant | 7h | 560 | 560 |
| 26 | 1.6.9 | Refit Office Complete | milestone | 0d | 2018-05-29 17:00 | 2018-05-29 17:00 | 25 | 2011-05-11 17:00 | 2011-05-11 17:00 | 0d | 0d |  |  |  |  |  |
